# Издание номера журнала

Schedule from MS Project, 2002-01-10 to 2002-04-12, status date 2002-02-10, costs in $.
MS Project 2002
Анализ длительности проекта по методике PERT -- заполняем поля данными и запускаем пересчет.

## Calendars

- Standard: Mon-Thu 09:00-12:00, 13:00-18:00; Fri 08:00-12:00, 13:00-17:00; Sat-Sun off. Exceptions (off unless hours are given): 2002-02-25, 2002-03-08.

## Resources

| Resource | Group | Rate | Cost per use |
| --- | --- | --- | --- |
| Иванов | Редактор раздела | 6.25 |  |
| Бумага для типографии |  | 15 |  |
| Фотомодель по контракту | Фотомодель |  | 200 |
| Терехов | Оператор печатного аппарата |  |  |
| Тарарухин | Оператор печатного аппарата |  |  |
| Борисов | Оператор печатного аппарата |  |  |
| Семенов | Оператор Mac |  |  |
| Бурков | Оператор Mac |  |  |
| Лимонов | Оператор Mac |  |  |
| Улендеева | Верстальщик |  |  |
| Сергеева | Верстальщик |  |  |
| Жуков | Фотограф |  |  |
| Еремин | Дизайнер |  |  |
| Ураганов | Корректор |  |  |
| Баранов | Корректор |  |  |
| Козлов | Технический редактор |  |  |
| Васин | Технический редактор |  |  |
| Уваров | Главный редактор |  |  |
| Галкина | Отвественный секретарь |  |  |
| Сидоров | Редактор раздела |  |  |
| Петров | Редактор раздела |  |  |
| Краска для вывода пленок |  | 100 |  |
| Фотопленка |  | 1.5 |  |
| Тарасова | Верстальщик |  |  |

## Schedule

| ID | WBS | Task | Type | Duration | Start | Finish | Predecessors | Total slack | Free slack | Constraint | Resources | Work | Cost |
| --- | --- | --- | --- | --- | --- | --- | --- | --- | --- | --- | --- | --- | --- |
| 1 | МАЙ//001 | **Планирование номера** |  | 11.44d | 2002-01-10 | 2002-01-25 |  | -0.27d | 0d |  |  | 81.33h | 141.66 |
| 2 | МАЙ//001.A | Сбор предложений от авторов |  | 5d | 2002-01-10 | 2002-01-16 |  | -0.27d | 0d |  | Иванов [25%]; Петров [25%]; Сидоров [25%] | 15h | 31.25 |
| 3 | МАЙ//001.B | Подготовка плана номера |  | 3d | 2002-01-17 | 2002-01-21 | 2 | -0.27d | 0d |  | Иванов [25%]; Петров [25%]; Сидоров [25%]; Уваров [12.5%] | 20h | 37.5 |
| 4 | МАЙ//001.C | Предварительная редколлегия |  | 3.17h | 2002-01-22 | 2002-01-22 | 3 | -0.27d | 0d |  | Иванов; Петров; Сидоров; Галкина; Уваров | 15.83h | 19.79 |
| 5 | МАЙ//001.D | Доработка планов с учетом замечаний |  | 3d | 2002-01-22 | 2002-01-25 | 4 | -0.27d | 0d |  | Иванов [25%]; Петров [25%]; Сидоров [25%] | 18h | 37.5 |
| 6 | МАЙ//001.E | Редколлегия |  | 2.5h | 2002-01-25 | 2002-01-25 | 5 | -0.27d | 0d | start no later than 2002-01-25 | Иванов; Петров; Сидоров; Галкина; Уваров | 12.5h | 15.62 |
| 7 | МАЙ//001.F | План номера утвержден | milestone | 0d | 2002-01-25 | 2002-01-25 | 6FS-1h | 0d |  |  |  |  |  |
| 8 | МАЙ//002 | **Подготовка материалов** |  | 41.06d | 2002-01-25 | 2002-03-27 | 7 | 0d |  |  |  | 399.13h | 516.39 |
| 9 | МАЙ//002.A | **Подготовка обложки** |  | 36.25d | 2002-02-01 | 2002-03-27 |  | 0d |  |  |  | 82.32h | 121.03 |
| 10 | МАЙ//002.A-a | Отбор модели |  | 13.83h | 2002-02-01 | 2002-02-04 |  | 0d |  | must start on 2002-02-01 | Еремин [50%] | 6.92h |  |
| 11 | МАЙ//002.A-b | Фотосъемка модели |  | 3d | 2002-02-04 | 2002-02-07 | 10 | 28.52d |  |  | Жуков; Фотомодель по контракту [57.1%]; Фотопленка [18.8%] | 37h | 121.03 |
| 12 | МАЙ//002.A-c | Подготовка анонсов материалов номера для обложки |  | 3d | 2002-03-19 | 2002-03-22 | 22FS-5% | 0d |  |  | Сидоров [70%] | 16.8h |  |
| 13 | МАЙ//002.A-d | Передача рекламных анонсов в предыдущий номер | milestone | 1d | 2002-03-05 | 2002-03-06 | 22FS-5% | 26.23d |  |  |  |  |  |
| 14 | МАЙ//002.A-e | Верстка обложки |  | 3d | 2002-03-22 | 2002-03-27 | 12, 11 | 0d |  |  | Еремин [70%]; Жуков [20%] | 21.6h |  |
| 15 | МАЙ//002.A-f | Обложка готова | milestone | 0d | 2002-03-27 | 2002-03-27 | 14 | 0d |  |  |  |  |  |
| 16 | МАЙ//002.B | **Подготовка текстов** |  | 34.1d | 2002-01-25 | 2002-03-18 |  | 0d |  |  |  | 316.81h | 395.36 |
| 17 | МАЙ//002.B-a | Подготовка редакционных заданий |  | 3.17d | 2002-01-25 | 2002-01-30 |  | 0d |  | start no later than 2002-01-25 | Иванов; Петров; Сидоров; Галкина | 70.43h | 107.29 |
| 18 | МАЙ//002.B-b | Рассылка заданий авторам |  | 1.34d | 2002-01-30 | 2002-01-31 | 17 | 0d |  |  | Галкина [33.3%] | 1.96h |  |
| 19 | МАЙ//002.B-c | Утверждение заданий авторами |  | 4d | 2002-01-31 | 2002-02-06 | 18 | 0d |  |  | Галкина [12.5%] | 4h |  |
| 20 | МАЙ//002.B-d | Статьи в работе у авторов | milestone | 0d | 2002-02-06 | 2002-02-06 | 19 | 0d |  |  |  |  |  |
| 21 | МАЙ//002.B-e | Статьи поступили в редакцию | milestone | 0d | 2002-02-20 | 2002-02-20 | 20FS+10d | 0d |  |  |  |  |  |
| 22 | 002.B-f | Редактирование материалов |  | 15.59d | 2002-02-20 | 2002-03-18 | 21 | 0d |  |  | Иванов [50%]; Петров [53.3%]; Сидоров [41.6%] | 160h | 259.73 |
| 23 | МАЙ//002.B-g | Техническое редактирование |  | 4.17d | 2002-02-22 | 2002-03-01 | 22SS+2d | 5.56d | 0d |  | Иванов [30%]; Петров [30%]; Сидоров [30%]; Галкина [50%]; Васин; Козлов | 80.42h | 28.34 |
| 24 | МАЙ//002.B-h | Тексты готовы | milestone | 0d | 2002-03-01 | 2002-03-01 | 23 | 28.86d |  |  |  |  |  |
| 25 | МАЙ//002.C | Подготовка материалов завершена | milestone | 0d | 2002-03-01 | 2002-03-01 | 23 | 28.86d |  |  |  |  |  |

Notes:
- 2: Text1: Файл предложений в редакционном формате.
- 3: Text1: План номера в формате XLS с названиями статей от редакторов разделов.
- 4: Text1: Предварительный план номиера обсужден.
- 5: Text1: Планы каждого из редакторов разделов доработаны с учетом замечаний.
- 6: Задания на этот номер должны включать темы: / ·летний отдых; / ·фотокамеры; / ·видеокамеры. / Text1: Окончательный план номера согласован с редакторами разделов и главным редактором.
- 13: Шаблон документа для передачи анонсов.

| ID | WBS | Task | Type | Duration | Start | Finish | Predecessors | Total slack | Free slack | Constraint | Resources | Work | Cost |
| --- | --- | --- | --- | --- | --- | --- | --- | --- | --- | --- | --- | --- | --- |
| 26 | МАЙ//003 | **Верстка журнала** |  | 24.54d | 2002-02-28 | 2002-04-05 |  | 5.49d |  |  |  | 502.08h | 155.28 |
| 27 | МАЙ//003.A | Обработка текста и иллюстраций |  | 10.17d | 2002-02-28 | 2002-03-15 | 23SS+3d | 5.56d | 0d |  | Тарасова [98.4%]; Улендеева [98.4%] | 160h |  |
| 28 | МАЙ//003.B | Вычитка |  | 20.17d | 2002-03-05 | 2002-04-03 | 27SS+3d | 6.86d | 4.19d |  | Баранов [50%]; Ураганов [50%] | 161.33h |  |
| 29 | МАЙ//003.C | Сверка |  | 14.35d | 2002-03-18 | 2002-04-05 | 28SS+3d | 5.49d |  | start no earlier than 2002-03-18 | Иванов [30%]; Петров [30%]; Сидоров [50%]; Баранов [50%]; Ураганов [50%] | 170.75h | 155.28 |
| 30 | МАЙ//003.D | Подготовка оглавления |  | 1.83d | 2002-03-15 | 2002-03-19 | 27 | 5.56d |  |  | Сидоров [45%] | 3.67h |  |
| 31 | МАЙ//003.E | Окончательная сборка |  | 2.17d | 2002-03-27 | 2002-03-29 | 30, 15 | 0d |  |  | Сидоров [62.5%]; Васин [25%] | 6.33h |  |
| 32 | МАЙ//003.F | Номер сверстан | milestone | 0d | 2002-03-29 | 2002-03-29 | 31 | 0d |  |  |  |  |  |
| 33 | МАЙ//004 | **Предпечатная подготовка** |  | 10.3d | 2002-03-29 | 2002-04-12 | 32 | 0d |  |  |  | 306.24h | 860.62 |
| 34 | МАЙ//004.A | Конвертция сверстанного номера в формат Mac |  | 6.25d | 2002-03-29 | 2002-04-02 |  | 0d |  |  | Лимонов [76.9%]; Бурков; Семенов [76.9%] | 92.38h |  |
| 35 | МАЙ//004.B | Цветоделение |  | 6.83d | 2002-04-02 | 2002-04-08 | 34 | 0d |  |  | Бурков [20%]; Семенов [20%]; Борисов [25%]; Тарарухин [20%]; Терехов [20%]; Бумага для типографии [12.5%] | 43.56h | 70.62 |
| 36 | МАЙ//004.C | Коррекция |  | 6.92d | 2002-04-03 | 2002-04-07 | 35SS+1d | 0d |  |  | Лимонов [25%]; Бурков [25%]; Семенов [25%] | 41.5h |  |
| 37 | МАЙ//004.D | Вывод пленок |  | 10.84d | 2002-04-05 | 2002-04-12 | 36SS+2d | 0d |  | finish no later than 2002-04-20 | Лимонов [34.8%]; Бурков [34.8%]; Борисов [41.8%]; Тарарухин [41.8%]; Терехов [41.8%]; Краска для вывода пленок [17.4%] | 128.8h | 790 |
| 38 | МАЙ//004.E | Номер готов к передаче в типографию | milestone | 0d | 2002-04-12 | 2002-04-12 | 37 | 0d |  |  |  |  |  |
